# Projectplan

How a schedule from MS Project changed from version to version. A marks actual dates.

## Version 1 (saved 2024-03-07, file Projectplan.mpp)

| ID | WBS | Task | Duration | Start | Finish | Predecessors | Complete | Total float | Constraint |
| --- | --- | --- | --- | --- | --- | --- | --- | --- | --- |
| 1 | 1 | **Oppstartsfase** | 14d | 2024-01-08 A | 2024-01-25 A |  | 100% |  |  |
| 2 | 1.1 | **Administrativt** | 7d | 2024-01-08 A | 2024-01-16 A |  | 100% |  |  |
| 3 | 1.1.1 | **Prosjektplan** | 7d | 2024-01-08 A | 2024-01-16 A |  | 100% |  |  |
| 4 |  | Opprette Prosjektplan Microsoft Project | 7d | 2024-01-08 A | 2024-01-16 A |  | 100% |  | start no earlier than 2024-01-08 |
| 5 | 1.1.2 | **Mal timeføring** | 5d | 2024-01-08 A | 2024-01-12 A |  | 100% |  |  |
| 6 |  | Makroaktivert Excelark for timeføring | 5d | 2024-01-08 A | 2024-01-12 A |  | 100% |  |  |
| 7 | 1.1.3 | **Tilgjenglighet utstyr** | 1d | 2024-01-15 A | 2024-01-15 A |  | 100% |  |  |
| 8 |  | Finne tilgjengelig utstyr på NTNU | 1d | 2024-01-15 A | 2024-01-15 A |  | 100% |  |  |
| 9 | 1.2 | **Befaring** | 8d | 2024-01-16 A | 2024-01-25 A |  | 100% |  |  |
| 10 |  | Forberedelse | 7d | 2024-01-16 A | 2024-01-24 A |  | 100% |  | start no earlier than 2024-01-16 |
| 11 |  | Urban Gartneren AS | 1d | 2024-01-25 A | 2024-01-25 A | 10 | 100% |  |  |
| 12 |  | Oppstartsfase fullført | 0d | 2024-01-25 | 2024-01-25 | 1 |  | 0d |  |
| 13 | 3 | **Prosjekteringsfase** | 26d | 2024-01-26 A | 2024-03-01 | 12 | 45% | 0d |  |
| 14 | 3.1 | **Administrativt** | 4d | 2024-02-12 A | 2024-02-15 A |  | 100% |  |  |
| 15 | 3.1.1 | **Budsjett** | 2d | 2024-02-12 A | 2024-02-13 A |  | 100% |  |  |
| 16 |  | Lage budsjett | 2d | 2024-02-12 A | 2024-02-13 A |  | 100% |  |  |
| 17 | 3.1.2 | **Innkjøp** | 2d | 2024-02-14 A | 2024-02-15 A |  | 100% |  |  |
| 18 |  | Sende bestillinger | 2d | 2024-02-14 A | 2024-02-15 A | 16 | 100% |  |  |
| 19 | 3.2 | **Bygg** | 11d | 2024-01-26 A | 2024-02-09 |  | 9% | 0d |  |
| 20 | 3.2.1 | **Prosjektering** | 6d | 2024-01-26 | 2024-02-02 |  |  | 0d |  |
| 21 |  | 3D-modell | 6d | 2024-01-26 | 2024-02-02 |  |  |  |  |
| 22 | 3.2.2 | **Dokumetnasjon** | 5d | 2024-02-05 A | 2024-02-09 | 20 | 20% | 0d |  |
| 23 |  | Finne frem nødvendig datablad | 2d | 2024-02-05 | 2024-02-06 | 21 |  |  |  |
| 24 |  | Oppdatere rapport | 2d | 2024-02-07 | 2024-02-08 |  |  |  |  |
| 25 |  | Oppdatere Wiki | 1d | 2024-02-09 A | 2024-02-09 A |  | 100% |  |  |
| 26 | 3.3 | **Vannbehandling** | 26d | 2024-01-26 A | 2024-03-01 |  | 32% | 0d |  |
| 27 | 3.3.1 | **Prosjektering** | 6d | 2024-01-26 A | 2024-02-02 A |  | 100% |  |  |
| 28 |  | Funksjonsbeskrivelse | 3d | 2024-01-26 A | 2024-01-30 A |  | 100% |  |  |
| 29 |  | RIV-tegning | 2d | 2024-01-31 A | 2024-02-01 A | 28 | 100% |  |  |
| 30 |  | Automatikkskjema | 1d | 2024-02-02 A | 2024-02-02 A | 29 | 100% |  |  |
| 31 | 3.3.2 | **Programmering** | 15d | 2024-02-05 A | 2024-02-23 | 27 | 22% | 0d |  |
| 32 | 3.3.2.1 | **Funksjonsblokk sirk.pumpe** | 2d | 2024-02-05 | 2024-02-06 |  |  | 0d |  |
| 33 |  | Research | 1d | 2024-02-05 | 2024-02-05 |  |  |  |  |
| 34 |  | Koding | 1d | 2024-02-05 | 2024-02-05 |  |  |  |  |
| 35 |  | Testing | 1d | 2024-02-06 | 2024-02-06 |  |  |  |  |
| 36 |  | Ferdigstillelse | 1d | 2024-02-06 | 2024-02-06 |  |  |  |  |
| 37 |  | Dokumentajson | 1d | 2024-02-06 | 2024-02-06 |  |  |  |  |
| 38 | 3.3.2.2 | **Funksjonsblokk shuntmotor** | 2d | 2024-02-08 A | 2024-02-09 A |  | 100% |  |  |
| 39 |  | Research | 1d | 2024-02-08 A | 2024-02-08 A |  | 100% |  |  |
| 40 |  | Koding | 1d | 2024-02-08 A | 2024-02-08 A |  | 100% |  |  |
| 41 |  | Testing | 1d | 2024-02-09 A | 2024-02-09 A |  | 100% |  |  |
| 42 |  | Ferdigstillelse | 1d | 2024-02-09 A | 2024-02-09 A |  | 100% |  |  |
| 43 |  | Dokumentajson | 1d | 2024-02-09 A | 2024-02-09 A |  | 100% |  |  |
| 44 | 3.3.2.3 | **Funksjonsblokk sensorer** | 2d | 2024-02-12 A | 2024-02-13 |  | 20% | 0d |  |
| 45 |  | Research | 1d | 2024-02-12 A | 2024-02-12 A |  | 100% |  |  |
| 46 |  | Koding | 1d | 2024-02-12 | 2024-02-12 |  |  |  |  |
| 47 |  | Testing | 1d | 2024-02-12 | 2024-02-12 |  |  |  |  |
| 48 |  | Ferdigstillelse | 1d | 2024-02-13 | 2024-02-13 |  |  |  |  |
| 49 |  | Dokumentajson | 1d | 2024-02-13 | 2024-02-13 |  |  |  |  |
| 50 | 3.3.2.4 | **Funksjonsblokk simulator** | 3d | 2024-02-14 | 2024-02-16 |  |  |  |  |
| 51 |  | Research | 1d | 2024-02-14 | 2024-02-14 |  |  |  |  |
| 52 |  | Koding | 1d | 2024-02-14 | 2024-02-14 |  |  |  |  |
| 53 |  | Testing | 1d | 2024-02-14 | 2024-02-14 |  |  |  |  |
| 54 |  | Ferdigstillelse | 1d | 2024-02-16 | 2024-02-16 |  |  |  |  |
| 55 |  | Dokumentajson | 1d | 2024-02-16 | 2024-02-16 |  |  |  |  |
| 56 | 3.3.2.5 | **Funksjonsblokk MQTT mot toppsystem** | 3d | 2024-02-19 | 2024-02-21 |  |  |  |  |
| 57 |  | Research | 1d | 2024-02-19 | 2024-02-19 |  |  |  |  |
| 58 |  | Koding | 1d | 2024-02-19 | 2024-02-19 |  |  |  |  |
| 59 |  | Testing | 1d | 2024-02-19 | 2024-02-19 |  |  |  |  |
| 60 |  | Ferdigstillelse | 1d | 2024-02-21 | 2024-02-21 |  |  |  |  |
| 61 |  | Dokumentajson | 1d | 2024-02-21 | 2024-02-21 |  |  |  |  |
| 62 |  | Offline testing mot simulator | 1d | 2024-02-22 | 2024-02-22 | 56 |  |  |  |
| 63 |  | Feilsøking | 1d | 2024-02-23 | 2024-02-23 | 62 |  |  |  |
| 64 | 3.3.3 | **Dokumentasjon** | 5d | 2024-02-26 | 2024-03-01 | 31 |  | 0d |  |
| 65 |  | Finne frem nødvendig datablad | 2d | 2024-02-26 | 2024-02-27 |  |  |  |  |
| 66 |  | Oppdatere rapport | 2d | 2024-02-28 | 2024-02-29 | 65 |  |  |  |
| 67 |  | Oppdatere Wiki | 1d | 2024-03-01 | 2024-03-01 | 66 |  |  |  |
| 68 | 3.4 | **Miljø og inneklima** | 26d | 2024-01-26 A | 2024-03-01 |  | 68% | 0d |  |
| 69 | 3.4.1 | **Prosjektering** | 6d | 2024-01-26 A | 2024-02-02 A |  | 100% |  |  |
| 70 |  | Funksjonsbeskrivelse | 3d | 2024-01-26 A | 2024-01-30 A |  | 100% |  |  |

| ID | WBS | Task | Duration | Start | Finish | Predecessors | Complete | Total float |
| --- | --- | --- | --- | --- | --- | --- | --- | --- |
| 71 |  | Prinsippskisse | 2d | 2024-01-31 A | 2024-02-01 A | 70 | 100% |  |
| 72 |  | Automatikkskjema | 1d | 2024-02-02 A | 2024-02-02 A | 71 | 100% |  |
| 73 | 3.4.2 | **Programmering** | 12d | 2024-02-08 A | 2024-02-23 | 72, 69 | 74% | 0d |
| 74 | 3.4.2.1 | **Funksjonsblokk temp.sensor** | 2d | 2024-02-08 A | 2024-02-09 A |  | 100% |  |
| 75 |  | Research | 1d | 2024-02-08 A | 2024-02-08 A |  | 100% |  |
| 76 |  | Koding | 1d | 2024-02-08 A | 2024-02-08 A |  | 100% |  |
| 77 |  | Testing | 1d | 2024-02-09 A | 2024-02-09 A |  | 100% |  |
| 78 |  | Ferdigstillelse | 1d | 2024-02-09 A | 2024-02-09 A |  | 100% |  |
| 79 |  | Dokumentajson | 1d | 2024-02-09 A | 2024-02-09 A |  | 100% |  |
| 80 | 3.4.2.2 | **Funksjonsblokk CO²-sesnor** | 2d | 2024-02-08 A | 2024-02-09 A |  | 100% |  |
| 81 |  | Research | 1d | 2024-02-08 A | 2024-02-08 A |  | 100% |  |
| 82 |  | Koding | 1d | 2024-02-08 A | 2024-02-08 A |  | 100% |  |
| 83 |  | Testing | 1d | 2024-02-09 A | 2024-02-09 A |  | 100% |  |
| 84 |  | Ferdigstillelse | 1d | 2024-02-09 A | 2024-02-09 A |  | 100% |  |
| 85 |  | Dokumentajson | 1d | 2024-02-09 A | 2024-02-09 A |  | 100% |  |
| 86 | 3.4.2.3 | **Funksjonsblokk luftfuktighetssensor** | 2d | 2024-02-12 A | 2024-02-13 A |  | 100% |  |
| 87 |  | Research | 1d | 2024-02-12 A | 2024-02-12 A |  | 100% |  |
| 88 |  | Koding | 1d | 2024-02-12 A | 2024-02-12 A |  | 100% |  |
| 89 |  | Testing | 1d | 2024-02-12 A | 2024-02-12 A |  | 100% |  |
| 90 |  | Ferdigstillelse | 1d | 2024-02-13 A | 2024-02-13 A |  | 100% |  |
| 91 |  | Dokumentajson | 1d | 2024-02-13 A | 2024-02-13 A |  | 100% |  |
| 92 | 3.4.2.4 | **Funksjonsblokk simulator** | 3d | 2024-02-14 A | 2024-02-16 A |  | 100% |  |
| 93 |  | Research | 1d | 2024-02-14 A | 2024-02-14 A |  | 100% |  |
| 94 |  | Koding | 1d | 2024-02-14 A | 2024-02-14 A |  | 100% |  |
| 95 |  | Testing | 1d | 2024-02-14 A | 2024-02-14 A |  | 100% |  |
| 96 |  | Ferdigstillelse | 1d | 2024-02-16 A | 2024-02-16 A |  | 100% |  |
| 97 |  | Dokumentajson | 1d | 2024-02-16 A | 2024-02-16 A |  | 100% |  |
| 98 | 3.4.2.5 | **Funksjonsblokk MQTT mot toppsystem** | 3d | 2024-02-19 | 2024-02-21 |  |  |  |
| 99 |  | Research | 1d | 2024-02-19 | 2024-02-19 |  |  |  |
| 100 |  | Koding | 1d | 2024-02-19 | 2024-02-19 |  |  |  |
| 101 |  | Testing | 1d | 2024-02-19 | 2024-02-19 |  |  |  |
| 102 |  | Ferdigstillelse | 1d | 2024-02-21 | 2024-02-21 |  |  |  |
| 103 |  | Dokumentajson | 1d | 2024-02-21 | 2024-02-21 |  |  |  |
| 104 |  | Offline testing mot simulator | 1d | 2024-02-22 | 2024-02-22 | 98 |  |  |
| 105 |  | Feilsøking | 1d | 2024-02-23 | 2024-02-23 | 104 |  |  |
| 106 | 3.4.3 | **Dokumetnasjon** | 5d | 2024-02-26 | 2024-03-01 | 73 |  | 0d |
| 107 |  | Finne frem nødvendig datablad | 2d | 2024-02-26 | 2024-02-27 |  |  |  |
| 108 |  | Oppdatere rapport | 2d | 2024-02-28 | 2024-02-29 | 107 |  |  |
| 109 |  | Oppdatere Wiki | 1d | 2024-03-01 | 2024-03-01 | 108 |  |  |
| 110 | 3.5 | **SD-anlegg/GUI** | 26d | 2024-01-26 A | 2024-03-01 |  | 35% | 0d |
| 111 | 3.5.1 | **Prosjektering** | 3d | 2024-01-26 A | 2024-01-30 A |  | 100% |  |
| 112 |  | Funksjonsbeskrivelse | 3d | 2024-01-26 A | 2024-01-30 A |  | 100% |  |
| 113 | 3.5.2 | **Programmering** | 15d | 2024-02-05 A | 2024-02-23 | 111 | 33% | 0d |
| 114 |  | Research CDP | 5d | 2024-02-05 A | 2024-02-09 A |  | 100% |  |
| 115 |  | Grafisk design | 3d | 2024-02-12 | 2024-02-14 | 114 |  |  |
| 116 |  | Funksjon ta imot MQTT fra vannbehandling | 2d | 2024-02-15 | 2024-02-16 |  |  |  |
| 117 |  | Funksjon ta imot MQTT fra Miljø og Inneklima | 2d | 2024-02-19 | 2024-02-20 |  |  |  |
| 118 |  | Offline testing | 1d | 2024-02-21 | 2024-02-21 | 117 |  |  |
| 119 |  | Feilsøking | 2d | 2024-02-22 | 2024-02-23 | 118 |  |  |
| 120 | 3.5.3 | **Dokumentasjon** | 5d | 2024-02-26 | 2024-03-01 | 113 |  | 0d |
| 121 |  | Finne frem nødvendig datablad | 2d | 2024-02-26 | 2024-02-27 |  |  |  |
| 122 |  | Oppdatere rapport | 2d | 2024-02-28 | 2024-02-29 | 121 |  |  |
| 123 |  | Oppdatere Wiki | 1d | 2024-03-01 | 2024-03-01 | 122 |  |  |
| 124 |  | Prosjekteringsfase fullført | 0d | 2024-03-01 | 2024-03-01 | 13 |  | 0d |
| 125 | 5 | **Gjennomføringsfasen** | 15d | 2024-03-04 | 2024-03-22 | 124 |  | 0d |
| 126 | 5.1 | **Administrativt** | 5d | 2024-03-04 | 2024-03-08 |  |  | 0d |
| 127 | 5.1.1 | **Testprotokoller** | 5d | 2024-03-04 | 2024-03-08 |  |  | 0d |
| 128 |  | Opprette mal for testprotokoller | 5d | 2024-03-04 | 2024-03-08 |  |  |  |
| 129 | 5.2 | **Bygg** | 10d | 2024-03-04 | 2024-03-15 |  |  | 0d |
| 130 | 5.2.1 | **Konstruksjon** | 5d | 2024-03-04 | 2024-03-08 |  |  | 0d |
| 131 |  | Montasje av utstyr på eksisterende konstruksjon | 5d | 2024-03-04 | 2024-03-08 |  |  |  |
| 132 | 5.2.2 | **Dokumentasjon** | 5d | 2024-03-11 | 2024-03-15 | 130 |  | 0d |
| 133 |  | Finne frem nødvendig datablad | 2d | 2024-03-11 | 2024-03-12 |  |  |  |
| 134 |  | Oppdatere rapport | 2d | 2024-03-13 | 2024-03-14 |  |  |  |
| 135 |  | Oppdatere Wiki | 1d | 2024-03-15 | 2024-03-15 |  |  |  |
| 136 | 5.3 | **Vannbehandling** | 15d | 2024-03-04 | 2024-03-22 |  |  | 0d |
| 137 | 5.3.1 | **Automatikkstyring** | 2d | 2024-03-04 | 2024-03-05 |  |  | 0d |
| 138 |  | Koble automatikkstyring | 2d | 2024-03-04 | 2024-03-05 |  |  |  |
| 139 | 5.3.2 | **Montasje** | 3d | 2024-03-06 | 2024-03-08 | 137 |  | 0d |
| 140 |  | Montering av utstyr og automatikk | 3d | 2024-03-06 | 2024-03-08 |  |  |  |

| ID | WBS | Task | Duration | Start | Finish | Predecessors | Total float |
| --- | --- | --- | --- | --- | --- | --- | --- |
| 141 | 5.3.3 | **Funksjonstesting** | 5d | 2024-03-11 | 2024-03-15 | 139 | 0d |
| 142 |  | Integrert test for systemet | 5d | 2024-03-11 | 2024-03-15 |  |  |
| 143 | 5.3.4 | **Dokumentasjon** | 5d | 2024-03-18 | 2024-03-22 | 141 | 0d |
| 144 |  | Finne frem nødvendig datablad | 2d | 2024-03-18 | 2024-03-19 |  |  |
| 145 |  | Oppdatere rapport | 2d | 2024-03-20 | 2024-03-21 | 144 |  |
| 146 |  | Oppdatere Wiki | 1d | 2024-03-22 | 2024-03-22 | 145 |  |
| 147 | 5.4 | **Miljø og Inneklima** | 15d | 2024-03-04 | 2024-03-22 |  | 0d |
| 148 | 5.4.1 | **Automatikkstyring** | 2d | 2024-03-04 | 2024-03-05 |  | 0d |
| 149 |  | Koble automatikkstyring | 2d | 2024-03-04 | 2024-03-05 |  |  |
| 150 | 5.4.2 | **Montasje** | 3d | 2024-03-06 | 2024-03-08 | 130, 148 | 0d |
| 151 |  | Montering av utstyr og automatikk | 3d | 2024-03-06 | 2024-03-08 |  |  |
| 152 | 5.4.3 | **Funksjonstesting** | 5d | 2024-03-11 | 2024-03-15 | 150 | 0d |
| 153 |  | Integrert test for systemet | 5d | 2024-03-11 | 2024-03-15 |  |  |
| 154 | 5.4.4 | **Dokumentasjon** | 5d | 2024-03-18 | 2024-03-22 | 152 | 0d |
| 155 |  | Finne frem nødvendig datablad | 2d | 2024-03-18 | 2024-03-19 |  |  |
| 156 |  | Oppdatere rapport | 2d | 2024-03-20 | 2024-03-21 | 155 |  |
| 157 |  | Oppdatere Wiki | 1d | 2024-03-22 | 2024-03-22 | 156 |  |
| 158 | 5.5 | **SD-anlegg/GUI** | 10d | 2024-03-11 | 2024-03-22 |  | 0d |
| 159 | 5.5.1 | **Funksjonstesting** | 5d | 2024-03-11 | 2024-03-15 |  | 0d |
| 160 |  | Integrert test for systemet | 5d | 2024-03-11 | 2024-03-15 |  |  |
| 161 | 5.5.2 | **Dokumentasjon** | 5d | 2024-03-18 | 2024-03-22 | 159 | 0d |
| 162 |  | Finne frem nødvendig datablad | 2d | 2024-03-18 | 2024-03-19 |  |  |
| 163 |  | Oppdatere rapport | 2d | 2024-03-20 | 2024-03-21 | 162 |  |
| 164 |  | Oppdatere Wiki | 1d | 2024-03-22 | 2024-03-22 | 163 |  |
| 165 |  | Gjennomføringsfase fullført | 0d | 2024-03-22 | 2024-03-22 | 125 | 6d |
| 166 | 7 | **Testfasen** | 9d | 2024-04-02 | 2024-04-12 | 165 | 0d |
| 167 | 7.1 | **FST (Fullskalatest)** | 4d | 2024-04-02 | 2024-04-05 |  | 0d |
| 168 |  | FST (Fullskalatest) | 2d | 2024-04-02 | 2024-04-03 |  |  |
| 169 |  | Feilsøking | 2d | 2024-04-04 | 2024-04-05 | 168 |  |
| 170 | 7.2 | **Dokumentasjon** | 5d | 2024-04-08 | 2024-04-12 |  | 0d |
| 171 |  | Fylle ut testprotokoller | 2d | 2024-04-08 | 2024-04-09 |  |  |
| 172 |  | Oppdatere rapport | 2d | 2024-04-10 | 2024-04-11 |  |  |
| 173 |  | Oppdatere Wiki | 1d | 2024-04-12 | 2024-04-12 |  |  |
| 174 |  | Testfase fullført | 0d | 2024-04-12 | 2024-04-12 | 166 | 0d |
| 175 | 9 | **Avsluttningsfase** | 12d | 2024-04-15 | 2024-04-30 | 174 | 0d |
| 176 |  | Rapportskriving | 10d | 2024-04-15 | 2024-04-26 |  |  |
| 177 |  | Wiki | 2d | 2024-04-29 | 2024-04-30 |  |  |
| 178 |  | Avsluttningsfase fullført | 0d | 2024-04-30 | 2024-04-30 | 175 | 0d |

## Version 2 (saved 2024-05-10, file Revidert Prosjektplan.mpp)

Last finish stays 2024-04-30. Complete tasks 42 → 114.

Removed: 147 Miljø og Inneklima; 148 Automatikkstyring; 149 Koble automatikkstyring; 150 Montasje; 151 Montering av utstyr og automatikk; 152 Funksjonstesting; 153 Integrert test for systemet; 154 Dokumentasjon; 155 Finne frem nødvendig datablad; 156 Oppdatere rapport; 157 Oppdatere Wiki

Changed:

| ID | Task | Start | Finish | Duration | Complete | Total float | Predecessors | Other |
| --- | --- | --- | --- | --- | --- | --- | --- | --- |
| 4 | Opprette Prosjektplan Microsoft Project |  |  | 7d → 3.9d |  |  |  |  |
| 12 | Oppstartsfase fullført | 2024-01-25 A | 2024-01-25 A |  | 0% → 100% | 0d → none |  |  |
| 13 | **Prosjekteringsfase** |  | 2024-03-01 A |  | 45% → 100% | 0d → none |  |  |
| 19 | **Bygg** |  | 2024-02-09 A |  | 9% → 100% | 0d → none |  |  |
| 20 | **Prosjektering** | 2024-01-26 A | 2024-02-02 A |  | 0% → 100% | 0d → none |  |  |
| 21 | 3D-modell | 2024-01-26 A | 2024-02-02 A |  | 0% → 100% |  |  |  |
| 22 | **Dokumetnasjon** |  | 2024-02-09 A |  | 20% → 100% | 0d → none |  |  |
| 23 | Finne frem nødvendig datablad | 2024-02-05 A | 2024-02-06 A |  | 0% → 100% |  |  |  |
| 24 | Oppdatere rapport | 2024-02-07 A | 2024-02-08 A |  | 0% → 100% |  |  |  |
| 26 | **Vannbehandling** |  | 2024-03-01 A |  | 32% → 100% | 0d → none |  |  |
| 31 | **Programmering** |  | 2024-02-23 A |  | 22% → 100% | 0d → none |  |  |
| 32 | **Funksjonsblokk sirk.pumpe** | 2024-02-05 A | 2024-02-06 A |  | 0% → 100% | 0d → none |  |  |
| 33 | Research | 2024-02-05 A | 2024-02-05 A |  | 0% → 100% |  |  |  |
| 34 | Koding | 2024-02-05 A | 2024-02-05 A |  | 0% → 100% |  |  |  |
| 35 | Testing | 2024-02-06 A | 2024-02-06 A |  | 0% → 100% |  |  |  |
| 36 | Ferdigstillelse | 2024-02-06 A | 2024-02-06 A |  | 0% → 100% |  |  |  |
| 37 | Dokumentajson | 2024-02-06 A | 2024-02-06 A |  | 0% → 100% |  |  |  |
| 39 | Research |  |  |  |  |  |  | resources Vegard → Joar |
| 40 | Koding |  |  |  |  |  |  | resources Vegard → Joar |
| 41 | Testing |  |  |  |  |  |  | resources Vegard → Joar |
| 42 | Ferdigstillelse |  |  |  |  |  |  | resources Vegard → Joar |
| 43 | Dokumentajson |  |  |  |  |  |  | resources Vegard → Joar |
| 44 | **Funksjonsblokk sensorer** |  | 2024-02-13 A |  | 20% → 100% | 0d → none |  |  |
| 45 | Research |  |  |  |  |  |  | resources Vegard → Joar |
| 46 | Koding | 2024-02-12 A | 2024-02-12 A |  | 0% → 100% |  |  | resources Vegard → Joar |
| 47 | Testing | 2024-02-12 A | 2024-02-12 A |  | 0% → 100% |  |  | resources Vegard → Joar |
| 48 | Ferdigstillelse | 2024-02-13 A | 2024-02-13 A |  | 0% → 100% |  |  | resources Vegard → Joar |
| 49 | Dokumentajson | 2024-02-13 A | 2024-02-13 A |  | 0% → 100% |  |  | resources Vegard → Joar |
| 50 | **Funksjonsblokk simulator** | 2024-02-14 A | 2024-02-16 A |  | 0% → 100% |  |  |  |
| 51 | Research | 2024-02-14 A | 2024-02-14 A |  | 0% → 100% |  |  | resources Vegard → Joar |
| 52 | Koding | 2024-02-14 A | 2024-02-14 A |  | 0% → 100% |  |  | resources Vegard → Joar |
| 53 | Testing | 2024-02-14 A | 2024-02-14 A |  | 0% → 100% |  |  | resources Vegard → Joar |
| 54 | Ferdigstillelse | 2024-02-16 A | 2024-02-16 A |  | 0% → 100% |  |  | resources Vegard → Joar |
| 55 | Dokumentajson | 2024-02-16 A | 2024-02-16 A |  | 0% → 100% |  |  | resources Vegard → Joar |
| 56 | **Funksjonsblokk MQTT mot toppsystem** | 2024-02-19 A | 2024-02-21 A |  | 0% → 100% |  |  |  |
| 57 | Research | 2024-02-19 A | 2024-02-19 A |  | 0% → 100% |  |  | resources Vegard → Peter |
| 58 | Koding | 2024-02-19 A | 2024-02-19 A |  | 0% → 100% |  |  | resources Vegard → Peter |
| 59 | Testing | 2024-02-19 A | 2024-02-19 A |  | 0% → 100% |  |  | resources Vegard → Peter |
| 60 | Ferdigstillelse | 2024-02-21 A | 2024-02-21 A |  | 0% → 100% |  |  | resources Vegard → Peter |
| 61 | Dokumentajson | 2024-02-21 A | 2024-02-21 A |  | 0% → 100% |  |  | resources Vegard → Peter |
| 62 | Offline testing mot simulator | 2024-02-22 A | 2024-02-22 A |  | 0% → 100% |  | 56 → none | resources Vegard → Peter |
| 63 | Feilsøking | 2024-02-23 A | 2024-02-23 A |  | 0% → 100% |  |  | resources Vegard → Peter |
| 64 | **Dokumentasjon** | 2024-02-26 A | 2024-03-01 A |  | 0% → 100% | 0d → none |  |  |
| 65 | Finne frem nødvendig datablad | 2024-02-26 A | 2024-02-27 A |  | 0% → 100% |  |  | resources Vegard → Kevin |
| 66 | Oppdatere rapport | 2024-02-28 A | 2024-02-29 A |  | 0% → 100% |  |  | resources Vegard → Kevin |
| 67 | Oppdatere Wiki | 2024-03-01 A | 2024-03-01 A |  | 0% → 100% |  |  | resources Vegard → Kevin |
| 68 | **Miljø og inneklima** |  | 2024-03-01 A |  | 68% → 100% | 0d → none |  |  |
| 73 | **Programmering** |  | 2024-02-23 A |  | 74% → 100% | 0d → none |  |  |
| 98 | **Funksjonsblokk MQTT mot toppsystem** | 2024-02-19 A | 2024-02-21 A |  | 0% → 100% |  |  |  |
| 99 | Research | 2024-02-19 A | 2024-02-19 A |  | 0% → 100% |  |  |  |
| 100 | Koding | 2024-02-19 A | 2024-02-19 A |  | 0% → 100% |  |  |  |
| 101 | Testing | 2024-02-19 A | 2024-02-19 A |  | 0% → 100% |  |  |  |
| 102 | Ferdigstillelse | 2024-02-21 A | 2024-02-21 A |  | 0% → 100% |  |  |  |
| 103 | Dokumentajson | 2024-02-21 A | 2024-02-21 A |  | 0% → 100% |  |  |  |
| 104 | Offline testing mot simulator | 2024-02-22 A | 2024-02-22 A |  | 0% → 100% |  |  |  |
| 105 | Feilsøking | 2024-02-23 A | 2024-02-23 A |  | 0% → 100% |  |  |  |
| 106 | **Dokumetnasjon** | 2024-02-26 A | 2024-03-01 A |  | 0% → 100% | 0d → none |  |  |
| 107 | Finne frem nødvendig datablad | 2024-02-26 A | 2024-02-27 A |  | 0% → 100% |  |  |  |
| 108 | Oppdatere rapport | 2024-02-28 A | 2024-02-29 A |  | 0% → 100% |  |  |  |
| 109 | Oppdatere Wiki | 2024-03-01 A | 2024-03-01 A |  | 0% → 100% |  |  |  |
| 110 | **SD-anlegg/GUI** |  | 2024-03-01 A |  | 35% → 100% | 0d → none |  |  |
| 113 | **Programmering** |  | 2024-02-23 A |  | 33% → 100% | 0d → none |  |  |
| 115 | Grafisk design | 2024-02-12 A | 2024-02-14 A |  | 0% → 100% |  |  |  |
| 116 | Funksjon ta imot MQTT fra vannbehandling | 2024-02-15 A | 2024-02-16 A |  | 0% → 100% |  |  |  |
| 117 | Funksjon ta imot MQTT fra Miljø og Inneklima | 2024-02-19 A | 2024-02-20 A |  | 0% → 100% |  |  |  |
| 118 | Offline testing | 2024-02-21 A | 2024-02-21 A |  | 0% → 100% |  |  |  |
| 119 | Feilsøking | 2024-02-22 A | 2024-02-23 A |  | 0% → 100% |  |  |  |
| 120 | **Dokumentasjon** | 2024-02-26 A | 2024-03-01 A |  | 0% → 100% | 0d → none |  |  |
| 121 | Finne frem nødvendig datablad | 2024-02-26 A | 2024-02-27 A |  | 0% → 100% |  |  |  |
| 122 | Oppdatere rapport | 2024-02-28 A | 2024-02-29 A |  | 0% → 100% |  |  |  |

| ID | Task | Start | Finish | Complete | Total float | Other |
| --- | --- | --- | --- | --- | --- | --- |
| 123 | Oppdatere Wiki | 2024-03-01 A | 2024-03-01 A | 0% → 100% |  |  |
| 124 | Prosjekteringsfase fullført | 2024-03-01 A | 2024-03-01 A | 0% → 100% | 0d → none |  |
| 125 | **Gjennomføringsfasen** | 2024-03-04 A | 2024-03-22 A | 0% → 100% | 0d → none |  |
| 126 | **Administrativt** | 2024-03-04 A | 2024-03-08 A | 0% → 100% | 0d → none |  |
| 127 | **Testprotokoller** | 2024-03-04 A | 2024-03-08 A | 0% → 100% | 0d → none |  |
| 128 | Opprette mal for testprotokoller | 2024-03-04 A | 2024-03-08 A | 0% → 100% |  |  |
| 129 | **Bygg** | 2024-03-04 A | 2024-03-15 A | 0% → 100% | 0d → none |  |
| 130 | **Konstruksjon** | 2024-03-04 A | 2024-03-08 A | 0% → 100% | 0d → none |  |
| 131 | Montasje av utstyr på eksisterende konstruksjon | 2024-03-04 A | 2024-03-08 A | 0% → 100% |  | resources Peter → Kevin |
| 132 | **Dokumentasjon** | 2024-03-11 A | 2024-03-15 A | 0% → 100% | 0d → none |  |
| 133 | Finne frem nødvendig datablad | 2024-03-11 A | 2024-03-12 A | 0% → 100% |  |  |
| 134 | Oppdatere rapport | 2024-03-13 A | 2024-03-14 A | 0% → 100% |  |  |
| 135 | Oppdatere Wiki | 2024-03-15 A | 2024-03-15 A | 0% → 100% |  |  |
| 136 | **Vannbehandling** | 2024-03-04 A | 2024-03-22 A | 0% → 100% | 0d → none |  |
| 137 | **Automatikkstyring** | 2024-03-04 A | 2024-03-05 A | 0% → 100% | 0d → none |  |
| 138 | Koble automatikkstyring | 2024-03-04 A | 2024-03-05 A | 0% → 100% |  | resources Vegard → Kevin |
| 139 | **Montasje** | 2024-03-06 A | 2024-03-08 A | 0% → 100% | 0d → none |  |
| 140 | Montering av utstyr og automatikk | 2024-03-06 A | 2024-03-08 A | 0% → 100% |  | resources Vegard → Kevin |
| 141 | **Funksjonstesting** | 2024-03-11 A | 2024-03-15 A | 0% → 100% | 0d → none |  |
| 142 | Integrert test for systemet | 2024-03-11 A | 2024-03-15 A | 0% → 100% |  | resources Vegard → Kevin |
| 143 | **Dokumentasjon** | 2024-03-18 A | 2024-03-22 A | 0% → 100% | 0d → none |  |
| 144 | Finne frem nødvendig datablad | 2024-03-18 A | 2024-03-19 A | 0% → 100% |  | resources Vegard → Kevin |
| 145 | Oppdatere rapport | 2024-03-20 A | 2024-03-21 A | 0% → 100% |  | resources Vegard → Kevin |
| 146 | Oppdatere Wiki | 2024-03-22 A | 2024-03-22 A | 0% → 100% |  | resources Vegard → Kevin |
| 147 | **SD-anlegg/GUI** | 2024-03-11 A | 2024-03-22 A | 0% → 100% | 0d → none |  |
| 148 | **Funksjonstesting** | 2024-03-11 A | 2024-03-15 A | 0% → 100% | 0d → none |  |
| 149 | Integrert test for systemet | 2024-03-11 A | 2024-03-15 A | 0% → 100% |  |  |
| 150 | **Dokumentasjon** | 2024-03-18 A | 2024-03-22 A | 0% → 100% | 0d → none |  |
| 151 | Finne frem nødvendig datablad | 2024-03-18 A | 2024-03-19 A | 0% → 100% |  |  |
| 152 | Oppdatere rapport | 2024-03-20 A | 2024-03-21 A | 0% → 100% |  |  |
| 153 | Oppdatere Wiki | 2024-03-22 A | 2024-03-22 A | 0% → 100% |  |  |
| 154 | Gjennomføringsfase fullført | 2024-03-22 A | 2024-03-22 A | 0% → 100% | 6d → none |  |
| 155 | **Testfasen** | 2024-04-02 A | 2024-04-12 A | 0% → 100% | 0d → none |  |
| 156 | **FST (Fullskalatest)** | 2024-04-02 A | 2024-04-05 A | 0% → 100% | 0d → none |  |
| 157 | FST (Fullskalatest) | 2024-04-02 A | 2024-04-03 A | 0% → 100% |  | resources Joar; Kevin; Peter; Vegard → Joar; Kevin; Peter |
| 158 | Feilsøking | 2024-04-04 A | 2024-04-05 A | 0% → 100% |  | resources Joar; Kevin; Peter; Vegard → Joar; Kevin; Peter |
| 159 | **Dokumentasjon** | 2024-04-08 A | 2024-04-12 A | 0% → 100% | 0d → none |  |
| 160 | Fylle ut testprotokoller | 2024-04-08 A | 2024-04-09 A | 0% → 100% |  | resources Joar; Kevin; Peter; Vegard → Joar; Kevin; Peter |
| 161 | Oppdatere rapport | 2024-04-10 A | 2024-04-11 A | 0% → 100% |  | resources Joar; Kevin; Peter; Vegard → Joar; Kevin; Peter |
| 162 | Oppdatere Wiki | 2024-04-12 A | 2024-04-12 A | 0% → 100% |  | resources Joar; Kevin; Peter; Vegard → Joar; Kevin; Peter |
| 163 | Testfase fullført | 2024-04-12 A | 2024-04-12 A | 0% → 100% | 0d → none |  |
| 164 | **Avsluttningsfase** | 2024-04-15 A | 2024-04-30 A | 0% → 100% | 0d → none |  |
| 165 | Rapportskriving | 2024-04-15 A | 2024-04-26 A | 0% → 100% |  | resources Joar; Kevin; Peter; Vegard → Joar; Kevin; Peter |
| 166 | Wiki | 2024-04-29 A | 2024-04-30 A | 0% → 100% |  | resources Joar; Kevin; Peter; Vegard → Joar; Kevin; Peter |
| 167 | Avsluttningsfase fullført | 2024-04-30 A | 2024-04-30 A | 0% → 100% | 0d → none |  |
